| id | name | startDate | endDate | priority | barScale | progress | type | parentId | dependencies |
| --- | --- | --- | --- | --- | --- | --- | --- | --- | --- |
| 1 | Office Relocation | 2026-06-01T00:00:00.000Z | 2026-10-31T00:00:00.000Z | medium | 1 | 0 | group |  |  |
| 2 | Relocation kickoff & committee | 2026-06-01T00:00:00.000Z | 2026-06-06T00:00:00.000Z | medium | 1 | 0 | task | 1 |  |
| 3 | Needs analysis & budget | 2026-06-06T00:00:00.000Z | 2026-06-21T00:00:00.000Z | high | 1 | 0 | task | 1 | 2 FS |
| 4 | Site search & tours | 2026-06-21T00:00:00.000Z | 2026-07-11T00:00:00.000Z | medium | 1 | 0 | task | 1 | 3 FS |
| 5 | Negotiate & sign lease | 2026-07-13T00:00:00.000Z | 2026-07-14T00:00:00.000Z | high | 1 | 0 | milestone | 1 | 4 FS |
| 6 | Space planning & design | 2026-07-14T00:00:00.000Z | 2026-08-08T00:00:00.000Z | medium | 1 | 0 | task | 1 | 5 FS |
| 7 | Internal communications plan | 2026-07-14T00:00:00.000Z | 2026-07-29T00:00:00.000Z | medium | 1 | 0 | task | 1 | 5 FS |
| 8 | Order furniture | 2026-07-15T00:00:00.000Z | 2026-07-25T00:00:00.000Z | medium | 1 | 0 | task | 1 | 5 FS |
| 9 | IT & telecom infrastructure planning | 2026-07-16T00:00:00.000Z | 2026-08-05T00:00:00.000Z | medium | 1 | 0 | task | 1 | 5 FS |
| 10 | Fit-out and construction | 2026-08-08T00:00:00.000Z | 2026-09-22T00:00:00.000Z | high | 1 | 0 | task | 1 | 6 FS |
| 11 | Hire movers & logistics | 2026-08-30T00:00:00.000Z | 2026-09-14T00:00:00.000Z | medium | 1 | 0 | task | 1 | 5 FS |
| 12 | Update address, utilities & vendors | 2026-09-04T00:00:00.000Z | 2026-09-19T00:00:00.000Z | medium | 1 | 0 | task | 1 | 5 FS |
| 13 | IT & telecom install | 2026-09-09T00:00:00.000Z | 2026-09-29T00:00:00.000Z | high | 1 | 0 | task | 1 | 9 FS |
| 14 | Furniture delivery & install | 2026-09-22T00:00:00.000Z | 2026-09-30T00:00:00.000Z | medium | 1 | 0 | task | 1 | 8 FS, 10 FS |
| 15 | Pack & label | 2026-09-27T00:00:00.000Z | 2026-10-09T00:00:00.000Z | medium | 1 | 0 | task | 1 | 11 FS |
| 16 | Move weekend | 2026-10-12T00:00:00.000Z | 2026-10-13T00:00:00.000Z | high | 1 | 0 | milestone | 1 | 13 FS, 14 FS, 15 FS |
| 17 | IT setup & testing at new site | 2026-10-13T00:00:00.000Z | 2026-10-23T00:00:00.000Z | medium | 1 | 0 | task | 1 | 16 FS |
| 18 | Settle-in & snag list | 2026-10-23T00:00:00.000Z | 2026-10-31T00:00:00.000Z | medium | 1 | 0 | task | 1 | 17 FS |
